# BEDs_schedule_2012

Schedule from MS Project, 2012-07-23 to 2013-12-12.

## Calendars

- Standard: Mon-Fri 08:00-12:00, 13:00-17:00; Sat-Sun off.

## Schedule

| ID | WBS | Task | Type | Duration | Start | Finish | Predecessors | Total slack |
| --- | --- | --- | --- | --- | --- | --- | --- | --- |
| 1 | 1 | **Software** |  | 149d? | 2012-09-24 | 2013-04-18 |  | 0d |
| 2 | 1.1 | RTC integration | manual | 18d | 2012-09-24 | 2012-10-17 |  |  |
| 3 | 1.2 | Board bringup | manual | 20d | 2013-02-04 | 2013-03-01 | 21 |  |
| 4 | 1.3 | Localization code | manual | 1d? | 2012-09-24 | 2012-09-24 |  |  |
| 5 | 1.4 | **Sensor integration** |  | 20d | 2013-02-04 | 2013-03-01 |  | 0d |
| 6 | 1.4.1 | Environmental | manual | 5d | 2013-02-04 | 2013-02-08 | 21 |  |
| 7 | 1.4.2 | Load management | manual | 5d | 2013-02-11 | 2013-02-15 | 6 |  |
| 8 | 1.4.3 | A/D | manual | 5d | 2013-02-18 | 2013-02-22 | 7 |  |
| 9 | 1.4.4 | Pressure | manual | 5d | 2013-02-25 | 2013-03-01 | 8 |  |
| 10 | 1.5 | **Shore Side** |  | 15d | 2013-01-30 | 2013-02-19 |  | 0d |
| 11 | 1.5.1 | LBL survey cleanup (matlab) | manual | 5d | 2013-01-30 | 2013-02-05 |  |  |
| 12 | 1.5.2 | localization cleanup (matlab) | manual | 5d | 2013-01-30 | 2013-02-05 |  |  |
| 13 | 1.5.3 | VRML development | manual | 10d | 2013-02-06 | 2013-02-19 | 12 |  |
| 14 | 1.6 | **Wave Glider** |  | 42d? | 2013-02-20 | 2013-04-18 |  | 0d |
| 15 | 1.6.1 | Rudix integration | manual | 1d? | 2013-02-20 | 2013-02-20 |  |  |
| 16 | 1.6.2 | SMC event detection code | manual | 14d | 2013-02-20 | 2013-03-11 | 13 |  |
| 17 | 1.6.3 | SMC survey data collection code | manual | 14d | 2013-03-12 | 2013-03-29 | 16 |  |
| 18 | 1.6.4 | SMC acoustic gateway code | manual | 14d | 2013-04-01 | 2013-04-18 | 17 |  |
| 19 | 2 | **Electrical** |  | 37d? | 2013-01-28 | 2013-03-19 |  | 0d |
| 20 | 2.1 | Procure/assemble battery pack | manual | 1d? | 2013-01-28 | 2013-01-28 |  |  |
| 21 | 2.2 | Initial board bringup | manual | 5d | 2013-01-28 | 2013-02-01 |  |  |
| 22 | 2.3 | Final board checkout | manual | 12d | 2013-02-04 | 2013-02-19 | 21 |  |
| 23 | 2.4 | WG SMC integration/test | manual | 5d | 2013-02-20 | 2013-02-26 |  |  |
| 24 | 2.5 | WG towbody interface | manual | 10d | 2013-02-27 | 2013-03-12 | 23 |  |
| 25 | 2.6 | WG homing interface? | manual | 5d | 2013-03-13 | 2013-03-19 | 24 |  |

| ID | WBS | Task | Type | Duration | Start | Finish | Predecessors | Total slack |
| --- | --- | --- | --- | --- | --- | --- | --- | --- |
| 26 | 3 | **Mechanical** |  | 24d | 2013-01-28 | 2013-02-28 |  | 0d |
| 27 | 3.1 | Housing bracketry | manual | 4d | 2013-01-28 | 2013-01-31 |  |  |
| 28 | 3.2 | Housing assembly | manual | 7d | 2013-02-01 | 2013-02-11 | 27 |  |
| 29 | 3.3 | Sphere machining | manual | 7d | 2013-02-01 | 2013-02-11 | 27 |  |
| 30 | 3.4 | Pressure test | manual | 5d | 2013-02-12 | 2013-02-18 | 28 |  |
| 31 | 3.5 | Integration/Assembly | manual | 7d | 2013-02-20 | 2013-02-28 | 30 |  |
| 32 | 4 | **Systems** |  | 94d | 2012-07-23 | 2012-11-29 |  | 0d |
| 33 | 4.1 | Test Motion thresholds | manual | 14d | 2012-07-23 | 2012-08-09 |  |  |
| 34 | 4.2 | RTC calibration | manual | 5d | 2012-10-26 | 2012-11-01 | 21 |  |
| 35 | 4.3 | Tethered shallow water tests | manual | 5d | 2012-11-23 | 2012-11-29 | 19, 1, 26, 31 |  |
| 36 | 5 | Tank test | milestone, manual | 0d | 2013-03-05 | 2013-03-05 |  |  |
| 37 | 6 | Paragon test | milestone, manual | 0d | 2013-03-21 | 2013-03-21 |  |  |
| 38 | 7 | Carson deployment | milestone, manual | 0d | 2013-04-12 | 2013-04-12 |  |  |
| 39 | 8 | Carson survey | milestone, manual | 0d | 2013-04-15 | 2013-04-15 |  |  |
| 40 | 9 | Carson survey | milestone, manual | 0d | 2013-07-18 | 2013-07-18 |  |  |
| 41 | 10 | Carson recovery | milestone, manual | 0d | 2013-12-12 | 2013-12-12 |  |  |
| 42 | 11 | CDR | milestone, manual | 0d | 2013-12-10 | 2013-12-10 |  |  |
| 43 | 12 | **Operations** |  | 175d | 2013-04-12 | 2013-12-12 |  | 0d |
| 44 | 12.1 | Prototype Deployment | manual | 70d | 2013-04-12 | 2013-07-18 |  |  |
| 45 | 12.2 | Continued Deployment | manual | 106d | 2013-07-18 | 2013-12-12 |  |  |
